# MARS_Apr_2005

Schedule from MS Project, 2002-11-27 to 2006-01-27, A marks actual dates.
MBARI

## Calendars

- Standard: Mon-Fri 08:00-12:00, 13:00-17:00; Sat-Sun off.

## Schedule

| ID | WBS | Task | Type | Duration | Start | Finish | Predecessors | Complete | Remaining | Baseline start | Baseline finish | Baseline duration | Total slack | Free slack | Constraint |
| --- | --- | --- | --- | --- | --- | --- | --- | --- | --- | --- | --- | --- | --- | --- | --- |
| 2 | 1 | **MARS Permitting** |  | 290d | 2004-08-30 A | 2005-10-07 |  | 72% | 82d | 2002-11-27 | 2004-05-04 | 375d | 0d |  |  |
| 3 | 1.1 | 12 month EIR/EIS review process following acceptance application |  | 250d | 2004-08-30 A | 2005-08-12 |  | 83% | 42d |  |  |  | 0d |  |  |
| 4 | 1.2 | EA determination by SLC Commission | milestone | 0d | 2005-08-12 | 2005-08-12 | 3 |  |  |  |  |  | 0d |  | start no earlier than 2005-06-06 |
| 5 | 1.3 | CCC, CCWQCB, USACE reviews and determinations |  | 40d | 2005-08-15 | 2005-10-07 | 4 |  |  |  |  |  | 0d |  |  |
| 6 | 1.4 | Complete EA process | milestone | 0d | 2005-10-07 | 2005-10-07 | 5 |  |  |  |  |  | 0d |  |  |
| 7 | 2 | **Power Network (JPL/ U of W)** |  | 289d | 2004-06-01 A | 2005-07-08 |  | 80% | 56.9d | 2002-06-10 | 2004-12-03 | 650d | 145d |  |  |
| 8 | 2.1 | **JPL** |  | 289d | 2004-06-01 A | 2005-07-08 |  | 83% | 48.17d |  |  |  | 145d |  |  |
| 9 | 2.1.1 | Build and test 96 stages of MARS converters |  | 250d | 2004-06-01 A | 2005-05-16 |  | 95% | 12.5d |  |  |  | 194d |  | start no earlier than 2004-06-01 |
| 10 | 2.1.2 | MariPro deliver chassis to JPL (hold till needed) | milestone | 0d | 2005-03-14 A | 2005-03-14 A |  | 100% |  |  |  |  |  |  | start no earlier than 2005-03-14 |
| 11 | 2.1.3 | MariPro deliver MV housing, bulkhead, to JPL (hold till needed) | milestone | 0d | 2005-04-25 | 2005-04-25 |  |  |  |  |  |  | 210d | 0d | start no earlier than 2005-04-25 |
| 12 | 2.1.4 | MBARI deliver ODI penetrator assy to JPL (hold till needed) | milestone | 0d | 2005-04-11 A | 2005-04-11 A |  | 100% |  |  |  |  |  |  | start no earlier than 2005-04-11 |
| 13 | 2.1.5 | MBARI deliver ODI MV test connector to JPL (hold till needed) | milestone | 0d | 2005-04-11 A | 2005-04-11 A |  | 100% |  |  |  |  |  |  | start no earlier than 2005-04-11 |
| 14 | 2.1.6 | Receive MV input and output boards from U of W | milestone | 0d | 2005-05-23 | 2005-05-23 |  |  |  |  |  |  | 20d | 0d | start no earlier than 2005-05-23 |
| 15 | 2.1.7 | Tests leading to full power test in fluorinert |  | 20d | 2005-05-23 | 2005-06-17 | 14 |  |  |  |  |  | 105d | 0d |  |
| 16 | 2.1.8 | Test 10kv-400V converters in fluorinert in housing |  | 10d | 2005-06-20 | 2005-07-01 | 19FS+3d, 15 |  |  |  |  |  | 105d | 0d | start no earlier than 2004-11-01 |
| 17 | 2.1.9 | Deliver integrated and tested converters in power housing to MBARI |  | 5d | 2005-07-04 | 2005-07-08 | 16 |  |  |  |  |  | 105d | 0d | start no earlier than 2004-12-01 |
| 18 | 2.2 | **U of W** |  | 125d | 2004-12-06 A | 2005-05-27 |  | 73% | 33.97d |  |  |  | 175d |  |  |
| 19 | 2.2.1 | U of W deliver input coordinating and output plane boards to JPL | milestone | 0d | 2005-05-23 | 2005-05-23 | 14SS |  |  |  |  |  | 35d | 15d | start no earlier than 2005-05-23 |
| 20 | 2.2.2 | Deliver chassis to U of W | milestone | 0d | 2005-01-31 A | 2005-01-31 A |  | 100% |  |  |  |  |  |  | start no earlier than 2005-01-31 |
| 21 | 2.2.3 | Bench Test U of W LV sub system engineering elements at U of W |  | 20d | 2004-12-06 A | 2004-12-31 A |  | 100% |  | 2004-06-21 | 2004-07-30 | 30d |  |  | start no earlier than 2004-12-06 |
| 22 | 2.2.4 | Fabricate, stuff and test deployable LV system boards |  | 85d | 2005-01-03 A | 2005-04-29 |  | 75% | 21.25d |  |  |  | 205d |  | start no earlier than 2005-01-03 |
| 23 | 2.2.5 | Assemble deployable boards, test |  | 5d | 2005-05-02 | 2005-05-06 | 22 |  |  |  |  |  | 90d | 0d |  |
| 24 | 2.2.6 | FAT at U of W for LV and PMAC |  | 5d | 2005-05-09 | 2005-05-13 | 23 |  |  |  |  |  | 90d | 0d |  |
| 25 | 2.2.7 | Ship LV system to MBARI | milestone | 0d | 2005-05-27 | 2005-05-27 | 24FS+10d |  |  |  |  |  | 175d |  |  |

| ID | WBS | Task | Type | Duration | Start | Finish | Predecessors | Complete | Remaining | Baseline start | Baseline finish | Baseline duration | Total slack | Free slack | Constraint |
| --- | --- | --- | --- | --- | --- | --- | --- | --- | --- | --- | --- | --- | --- | --- | --- |
| 26 | 3 | **Data Communications (WHOI)** |  | 235d | 2004-06-07 A | 2005-05-02 |  | 78% | 52.22d | 2003-07-25 | 2004-12-03 | 355d | 195d |  |  |
| 27 | 3.1 | DCS Integration and test plan delivered to MBARI | milestone | 0d | 2005-05-02 A | 2005-05-02 |  | 75% | 0d | 2003-09-08 | 2003-09-08 | 0d | 205d |  | start no earlier than 2004-01-27 |
| 28 | 3.2 | DCS design mods, build science nodes and SS DCS |  | 70d | 2004-06-07 A | 2004-09-10 A |  | 100% |  |  |  |  |  |  |  |
| 29 | 3.3 | DCS science node and SS equipment testing |  | 20d | 2004-12-13 | 2005-01-07 |  |  |  |  |  |  | 285d |  | start no earlier than 2004-12-13 |
| 30 | 3.4 | Deliver node communications sub-system to U of W | milestone | 0d | 2005-03-15 A | 2005-03-15 A | 29 | 100% |  | 2004-08-02 | 2004-08-02 | 0d |  |  | start no earlier than 2005-03-15 |
| 31 | 4 | **LV Power and DCS testing at U of W** |  | 59d | 2005-03-15 A | 2005-06-03 |  | 17% | 49.17d |  |  |  | 170d |  |  |
| 32 | 4.1 | Ship DCS to U of W | milestone | 0d | 2005-03-15 A | 2005-03-15 A | 30SS | 100% |  |  |  |  |  |  | start no earlier than 2005-02-15 |
| 33 | 4.2 | Test DCS with LV engineering system |  | 40d | 2005-03-15 A | 2005-05-09 | 32 | 25% | 30d |  |  |  | 189d |  |  |
| 34 | 4.3 | Test DCS system with LV deployable system |  | 10d | 2005-05-16 | 2005-05-27 | 24 |  |  |  |  |  | 90d | 0d |  |
| 35 | 4.4 | Deliver LV system to MBARI |  | 5d | 2005-05-30 | 2005-06-03 | 34 |  |  |  |  |  | 90d | 0d |  |
| 36 | 4.5 | Deliver DCS to MBARI |  | 5d | 2005-05-30 | 2005-06-03 | 35SS |  |  |  |  |  | 90d | 0d |  |
| 37 | 5 | **OBC/Timing System** |  | 0d | 2005-04-04 | 2005-04-04 |  |  |  | 2003-07-25 | 2004-09-24 | 305d | 215d |  |  |
| 38 | 5.1 | Deliver OBC and node timing to U of W | milestone | 0d | 2005-04-04 | 2005-04-04 | 30SS |  |  | 2004-08-02 | 2004-08-02 | 0d | 215d |  | start no earlier than 2005-04-04 |
| 39 | 6 | **Node (MariPro)** |  | 635d? | 2002-11-27 A | 2005-05-03 |  | 9% | 580.16d? | 2002-11-27 | 2004-05-21 | 388d | 193d |  |  |
| 40 | 6.1 | Deliver wet and dry chassis's to U of W | milestone | 0d | 2005-02-07 A | 2005-02-07 A | 20SS | 100% |  |  |  |  |  |  | start no earlier than 2005-02-07 |
| 41 | 6.2 | Deliver chassis to JPL | milestone | 0d | 2005-04-18 A | 2005-04-18 A | 10SS | 100% |  |  |  |  |  |  | start no earlier than 2005-04-18 |
| 42 | 6.3 | Deliver MV housing, bulkhead, to JPL | milestone | 0d | 2005-04-25 | 2005-04-25 | 11SS |  |  |  |  |  | 200d |  | start no earlier than 2005-02-28 |
| 43 | 6.4 | Procure, fabricate and test node | milestone | 0d | 2005-04-25 A | 2005-04-25 |  | 95% | 0d |  |  |  | 200d |  | start no earlier than 2005-04-25 |
| 44 | 6.5 | Fabricate and test LV/comms housing, bulkheads, harnesses etc |  | 1d? | 2002-11-27 A | 2002-11-27 |  | 95% | 0.05d? |  |  |  | 827d |  |  |
| 45 | 6.6 | Deliver LV/comms housing to MBARI | milestone | 0d | 2005-04-27 | 2005-04-27 |  |  |  |  |  |  | 198d |  | start no earlier than 2005-04-27 |
| 46 | 6.7 | Deliver TRF to MBARI |  | 5d | 2005-04-27 | 2005-05-03 |  |  |  |  |  |  | 178d | 0d | start no earlier than 2005-04-27 |
| 47 | 6.8 | Deliver node to MBARI |  | 5d | 2005-04-27 | 2005-05-03 |  |  |  |  |  |  | 83d | 0d | start no earlier than 2005-04-27 |
| 48 | 7 | **Cable Specification and Procurement** |  | 60d | 2002-12-02 A | 2003-02-21 A |  | 100% |  | 2002-11-04 | 2004-01-30 | 325d |  |  |  |
| 49 | 7.1 | Ship backbone cable to storage location |  | 60d | 2002-12-02 A | 2003-02-21 A |  | 100% |  | 2002-12-02 | 2003-02-21 | 60d |  |  | start no earlier than 2002-12-02 |

| ID | WBS | Task | Type | Duration | Start | Finish | Predecessors | Complete | Remaining | Baseline start | Baseline finish | Baseline duration | Total slack | Free slack | Constraint |
| --- | --- | --- | --- | --- | --- | --- | --- | --- | --- | --- | --- | --- | --- | --- | --- |
| 50 | 8 | **Cable Termination Assembly** |  | 0d | 2005-01-17 | 2005-01-17 |  |  |  | 2003-08-18 | 2004-01-30 | 120d | 270d |  |  |
| 51 | 8.1 | Deliver CTA to MariPro/MBARI | milestone | 0d | 2005-01-17 | 2005-01-17 |  |  |  |  |  |  | 270d |  | start no earlier than 2005-01-17 |
| 52 | 9 | **MARS Shore Side Assembly, Integration and Test** |  | 113d | 2005-05-03 | 2005-10-07 |  |  |  | 2004-08-02 | 2004-12-03 | 90d | 80d |  |  |
| 53 | 9.1 | Receive MV system in housing from JPL | milestone | 0d | 2005-07-08 | 2005-07-08 | 17 |  |  |  |  |  | 125d | 0d | start no earlier than 2004-12-01 |
| 54 | 9.2 | Receive LV power sub system from U of W | milestone | 0d | 2005-06-03 | 2005-06-03 | 35 |  |  |  |  |  | 90d | 0d |  |
| 55 | 9.3 | Reveive DCS system from WHOI | milestone | 0d | 2005-06-03 | 2005-06-03 | 36 |  |  |  |  |  | 90d | 0d |  |
| 56 | 9.4 | Receive TRF from MariPro | milestone | 0d | 2005-05-03 | 2005-05-03 | 46 |  |  |  |  |  | 178d | 0d |  |
| 57 | 9.5 | Receive node from MariPro | milestone | 0d | 2005-05-03 | 2005-05-03 | 47 |  |  |  |  |  | 83d | 68d |  |
| 58 | 9.6 | **System integration and test at MBARI** |  | 108d | 2005-05-11 | 2005-10-07 |  |  |  |  |  |  | 80d |  |  |
| 59 | 9.6.1 | Bench test DCS, LV power sub systems |  | 15d | 2005-06-13 | 2005-07-01 | 55FS+5d, 54FS+5d |  |  |  |  |  | 90d | 10d |  |
| 60 | 9.6.2 | Bench test MV power sub systems |  | 5d | 2005-07-11 | 2005-07-15 | 53 |  |  |  |  |  | 125d | 0d |  |
| 61 | 9.6.3 | Bench test LV, MV and DCS sub systems |  | 5d | 2005-07-18 | 2005-07-22 | 59, 60 |  |  |  |  |  | 125d | 0d |  |
| 62 | 9.6.4 | Test ROV procedures TRF in test tank |  | 10d | 2005-05-11 | 2005-05-24 | 56FS+5d |  |  |  |  |  | 178d |  |  |
| 63 | 9.6.5 | Install MV and LV housings into node, dry test Blg D |  | 5d | 2005-07-25 | 2005-07-29 | 61 |  |  |  |  |  | 125d | 0d |  |
| 64 | 9.6.6 | Test node and TRF in test tank |  | 5d | 2005-08-01 | 2005-08-05 | 63, 65 |  |  |  |  |  | 125d |  |  |
| 65 | 9.6.7 | Fit TRF to CTA |  | 30d | 2005-05-25 | 2005-07-05 | 56FS+15d, 57FS+15d |  |  |  |  |  | 123d | 0d |  |
| 66 | 9.6.8 | Ship TRF and CTA to Ile de Dey |  | 25d | 2005-09-05 | 2005-10-07 | 65, 64FS+20d |  |  |  |  |  | 80d |  |  |
| 67 | 10 | **MARS Installation** |  | 10d | 2005-11-28 | 2005-12-09 |  |  |  | 2005-03-28 | 2005-05-06 | 30d | 35d |  |  |
| 68 | 10.1 | Installation |  | 10d | 2005-11-28 | 2005-12-09 | 6FS+30d, 79FS+15d |  |  |  |  |  | 35d |  | start no earlier than 2005-08-22 |
| 69 | 11 | **Shore Facility** |  | 828d? | 2002-11-27 A | 2006-01-27 |  | 29% | 591.25d? | 2003-01-13 | 2004-12-31 | 515d | 0d |  |  |
| 70 | 11.1 | **Shore Facility** |  | 828d? | 2002-11-27 A | 2006-01-27 |  | 29% | 591.25d? | 2003-01-13 | 2004-09-07 | 432d | 0d |  |  |
| 71 | 11.1.1 | Install PGE transformer, power pole |  | 90d | 2005-02-07 | 2005-06-10 |  |  |  |  |  |  | 165d |  | start no earlier than 2005-02-07 |
| 72 | 11.1.2 | **Modular Building** |  | 200d | 2004-11-08 A | 2005-08-12 |  | 55% | 90d |  |  |  | 120d |  |  |
| 73 | 11.1.2.1 | Prepare requirements for modular building |  | 90d | 2004-11-08 A | 2005-03-11 |  | 55% | 40.5d |  |  |  | 230d |  | start no earlier than 2004-11-08 |
| 74 | 11.1.2.2 | Release PO for modular building | milestone | 0d | 2005-05-02 | 2005-05-02 |  |  |  |  |  |  | 120d | 0d | start no earlier than 2005-05-02 |
| 75 | 11.1.2.3 | Deliver modular building to MBARI | milestone | 0d | 2005-08-12 | 2005-08-12 | 74FS+75d |  |  |  |  |  | 120d |  |  |

| ID | WBS | Task | Type | Duration | Start | Finish | Predecessors | Complete | Remaining | Baseline start | Baseline finish | Baseline duration | Total slack | Free slack | Constraint |
| --- | --- | --- | --- | --- | --- | --- | --- | --- | --- | --- | --- | --- | --- | --- | --- |
| 76 | 11.1.3 | **HDD** |  | 768d | 2002-11-27 | 2005-11-04 |  |  |  |  |  |  | 60d |  |  |
| 77 | 11.1.3.1 | Release HDD bid RFP | milestone | 0d | 2002-11-27 | 2002-11-27 |  |  |  |  |  |  | 788d | 0d |  |
| 78 | 11.1.3.2 | Place contract HDD | milestone | 0d | 2003-01-21 | 2003-01-21 | 77FS+40d |  |  |  |  |  | 788d |  |  |
| 79 | 11.1.3.3 | HDD |  | 10d | 2005-10-24 | 2005-11-04 | 6FS+10d |  |  |  |  |  | 0d |  |  |
| 80 | 11.1.4 | **Civil Work** |  | 793d? | 2002-11-27 | 2005-12-09 |  |  |  |  |  |  | 35d |  |  |
| 81 | 11.1.4.1 | Complete HBFL site construction package | milestone | 0d | 2005-06-06 | 2005-06-06 |  |  |  |  |  |  | 170d |  | start no earlier than 2005-06-06 |
| 82 | 11.1.4.2 | Release civil work RFP |  | 1d? | 2002-11-27 | 2002-11-27 |  |  |  |  |  |  | 827d |  |  |
| 83 | 11.1.4.3 | Foundations, trench for power/comms |  | 20d | 2005-11-14 | 2005-12-09 | 79FS+5d |  |  |  |  |  | 0d |  |  |
| 84 | 11.1.5 | Install modular building |  | 5d | 2006-01-09 | 2006-01-13 | 83FS+20d |  |  |  |  |  | 0d |  |  |
| 85 | 11.1.6 | Install land termination power and fiber to shore building |  | 5d | 2006-01-16 | 2006-01-20 | 84 |  |  | 2004-05-05 | 2004-09-07 | 90d | 0d |  |  |
| 86 | 11.1.7 | Identify requirements and preliminary design grounding system |  | 50d | 2005-03-14 A | 2005-05-20 |  | 90% | 5d | 2003-01-13 | 2003-06-27 | 120d | 113d | 0d | start no earlier than 2003-10-20 |
| 87 | 11.1.8 | Design grounding system |  | 60d | 2005-05-23 A | 2005-08-12 | 86 | 5% | 57d |  |  |  | 110d |  |  |
| 88 | 11.1.9 | Install grounding system, connect to shore building |  | 10d | 2006-01-16 | 2006-01-27 | 6FS+30d, 87, 79FS+15d, 85SS |  |  | 2004-05-05 | 2004-09-07 | 90d | 0d |  | start no earlier than 2005-10-03 |
