# MARS_Sept_2006

Schedule from MS Project, 2002-11-27 to 2007-05-14, A marks actual dates.
MBARI

## Calendars

- Standard: Mon-Fri 08:00-12:00, 13:00-17:00; Sat-Sun off. Exceptions (off unless hours are given): 2005-07-04, 2006-07-15 08:00-12:00, 13:00-17:00, 2006-12-22, 2006-12-25 to 2006-12-29, 2007-01-01.

## Schedule

| ID | WBS | Task | Type | Duration | Start | Finish | Predecessors | Complete | Remaining | Baseline start | Baseline finish | Baseline duration | Total slack | Constraint |
| --- | --- | --- | --- | --- | --- | --- | --- | --- | --- | --- | --- | --- | --- | --- |
| 2 | 1 | **MARS Permitting** |  | 320d | 2004-08-30 A | 2005-11-21 A |  | 100% |  | 2002-11-27 | 2004-05-04 | 375d |  |  |
| 3 | 1.1 | 12 month EIR/EIS review process following acceptance application |  | 250d | 2004-08-30 A | 2005-08-15 A |  | 100% |  |  |  |  |  |  |
| 4 | 1.2 | EA determination by SLC Commission | milestone | 0d | 2005-08-15 A | 2005-08-15 A | 3 | 100% |  |  |  |  |  | start no earlier than 2005-06-06 |
| 5 | 1.3 | CCC, CCWQCB, USACE reviews and determinations |  | 70d | 2005-08-16 A | 2005-11-21 A | 4 | 100% |  |  |  |  |  |  |
| 6 | 1.4 | Complete all permitting activities | milestone | 0d | 2005-11-21 A | 2005-11-21 A | 5 | 100% |  |  |  |  |  |  |
| 7 | 2 | **Power Network (JPL/ U of W)** |  | 166d | 2004-12-06 A | 2005-07-26 |  | 99% | 0d | 2002-06-10 | 2004-12-03 | 650d | 448d |  |
| 8 | 2.1 | **U of W** |  | 166d | 2004-12-06 A | 2005-07-26 |  | 99% | 0d |  |  |  | 448d |  |
| 9 | 2.1.1 | U of W deliver input coordinating and output plane boards to JPL | milestone | 0d | 2005-05-23 | 2005-05-23 |  |  |  |  |  |  | 477d | start no earlier than 2005-05-23 |
| 10 | 2.1.2 | Deliver chassis to U of W | milestone | 0d | 2005-01-31 A | 2005-01-31 A |  | 100% |  |  |  |  |  | start no earlier than 2005-01-31 |
| 11 | 2.1.3 | Bench Test U of W LV sub system engineering elements at U of W |  | 20d | 2004-12-06 A | 2004-12-31 A |  | 100% |  | 2004-06-21 | 2004-07-30 | 30d |  | start no earlier than 2004-12-06 |
| 12 | 2.1.4 | Fabricate, stuff and test deployable LV system boards |  | 85d | 2005-01-03 A | 2005-04-29 A |  | 100% |  |  |  |  |  | start no earlier than 2005-01-03 |
| 13 | 2.1.5 | Assemble deployable boards, test |  | 20d | 2005-05-02 A | 2005-05-27 A | 12 | 100% |  |  |  |  |  |  |
| 14 | 2.1.6 | U of W pre FAT for LV and PMAC |  | 10d | 2005-05-30 A | 2005-06-10 A | 13 | 100% |  |  |  |  |  | start no earlier than 2005-05-16 |
| 15 | 2.1.7 | FAT for LV and PMAC |  | 29d | 2005-06-13 A | 2005-07-22 A | 14 | 100% |  |  |  |  |  | start no earlier than 2005-06-13 |
| 16 | 2.1.8 | Ship LV system to MBARI |  | 2d | 2005-07-25 A | 2005-07-26 A | 15 | 100% |  |  |  |  |  |  |
| 17 | 3 | **Data Communications (WHOI)** |  | 34d | 2005-03-15 A | 2005-05-02 |  |  | 34d | 2003-07-25 | 2004-12-03 | 355d | 509d |  |
| 18 | 3.1 | DCS Integration and test plan delivered to MBARI | milestone | 0d | 2005-05-02 A | 2005-05-02 |  | 75% | 0d | 2003-09-08 | 2003-09-08 | 0d | 492d | start no earlier than 2004-01-27 |
| 19 | 3.2 | Deliver node communications sub-system to U of W | milestone | 0d | 2005-03-15 A | 2005-03-15 A |  | 100% |  | 2004-08-02 | 2004-08-02 | 0d |  | start no earlier than 2005-03-15 |
| 20 | 4 | **LV Power and DCS testing at U of W** |  | 79d | 2005-03-15 A | 2005-07-01 A |  | 100% |  |  |  |  |  |  |
| 21 | 4.1 | Ship DCS to U of W | milestone | 0d | 2005-03-15 A | 2005-03-15 A | 19SS | 100% |  |  |  |  |  | start no earlier than 2005-02-15 |
| 22 | 4.2 | Test DCS with LV engineering system |  | 40d | 2005-03-15 A | 2005-05-09 A | 21 | 100% |  |  |  |  |  |  |
| 23 | 4.3 | Test DCS system with LV deployable system |  | 10d | 2005-06-13 A | 2005-06-24 A |  | 100% |  |  |  |  |  | start no earlier than 2005-06-13 |
| 24 | 4.4 | Ship DCS to MBARI |  | 5d | 2005-06-27 A | 2005-07-01 A | 23 | 100% |  |  |  |  |  |  |
| 25 | 5 | **OBC/Timing System** |  | 0d | 2005-06-13 A | 2005-06-13 A |  | 100% |  | 2003-07-25 | 2004-09-24 | 305d |  |  |
| 26 | 5.1 | Deliver OBC and node timing to U of W | milestone | 0d | 2005-06-13 A | 2005-06-13 A | 19SS | 100% |  | 2004-08-02 | 2004-08-02 | 0d |  | start no earlier than 2005-06-13 |

| ID | WBS | Task | Type | Duration | Start | Finish | Predecessors | Complete | Remaining | Baseline start | Baseline finish | Baseline duration | Total slack | Free slack | Constraint |
| --- | --- | --- | --- | --- | --- | --- | --- | --- | --- | --- | --- | --- | --- | --- | --- |
| 27 | 6 | **Node (MariPro)** |  | 640d? | 2002-11-27 A | 2005-05-11 |  | 99% | 0d? | 2002-11-27 | 2004-05-21 | 388d | 502d |  |  |
| 28 | 6.1 | Deliver wet and dry chassis's to U of W | milestone | 0d | 2005-02-07 A | 2005-02-07 A | 10SS | 100% |  |  |  |  |  |  | start no earlier than 2005-02-07 |
| 29 | 6.2 | Deliver chassis to JPL | milestone | 0d | 2005-04-18 A | 2005-04-18 A |  | 100% |  |  |  |  |  |  | start no earlier than 2005-04-18 |
| 30 | 6.3 | Deliver MV housing, bulkhead, to JPL | milestone | 0d | 2005-05-11 | 2005-05-11 |  |  |  |  |  |  | 485d |  | start no earlier than 2005-05-11 |
| 31 | 6.4 | Procure, fabricate and test node | milestone | 0d | 2005-04-25 A | 2005-04-25 |  | 95% | 0d |  |  |  | 497d |  | start no earlier than 2005-04-25 |
| 32 | 6.5 | Fabricate and test LV/comms housing, bulkheads, harnesses etc |  | 1d? | 2002-11-27 A | 2002-11-27 A |  | 100% |  |  |  |  |  |  |  |
| 33 | 6.6 | Deliver LV/comms housing to MBARI | milestone | 0d | 2005-04-27 A | 2005-04-27 A |  | 100% |  |  |  |  |  |  | start no earlier than 2005-04-27 |
| 34 | 6.7 | Deliver TRF to MBARI |  | 5d | 2005-04-27 A | 2005-05-03 A |  | 100% |  |  |  |  |  |  | start no earlier than 2005-04-27 |
| 35 | 6.8 | Deliver node to MBARI |  | 5d | 2005-04-27 A | 2005-05-03 A |  | 100% |  |  |  |  |  |  | start no earlier than 2005-04-27 |
| 36 | 7 | **Cable Specification and Procurement** |  | 60d | 2002-12-02 A | 2003-02-21 A |  | 100% |  | 2002-11-04 | 2004-01-30 | 325d |  |  |  |
| 37 | 7.1 | Ship backbone cable to storage location |  | 60d | 2002-12-02 A | 2003-02-21 A |  | 100% |  | 2002-12-02 | 2003-02-21 | 60d |  |  | start no earlier than 2002-12-02 |
| 38 | 8 | **Cable Termination Assembly** |  | 0d | 2005-01-17 A | 2005-01-17 A |  | 100% |  | 2003-08-18 | 2004-01-30 | 120d |  |  |  |
| 39 | 8.1 | Deliver CTA to MBARI | milestone | 0d | 2005-01-17 A | 2005-01-17 A |  | 100% |  |  |  |  |  |  | start no earlier than 2005-01-17 |
| 40 | 9 | **MARS Shore Side Assembly, Integration and Test Deliveries** |  | 470d | 2005-05-03 A | 2007-03-01 |  | 50% | 236.82d | 2004-08-02 | 2004-12-03 | 90d | 67d |  |  |
| 41 | 9.1 | Receive MV system from Alcatel | milestone | 0d | 2006-07-10 | 2006-07-10 |  |  |  |  |  |  | 119d | 17d | start no earlier than 2006-07-10 |
| 42 | 9.2 | Receive LV power sub system from U of W | milestone | 0d | 2005-07-26 A | 2005-07-26 A | 16 | 100% |  |  |  |  |  |  |  |
| 43 | 9.3 | Receive DCS system from WHOI | milestone | 0d | 2005-07-01 A | 2005-07-01 A | 24 | 100% |  |  |  |  |  |  |  |
| 44 | 9.4 | Receive TRF from MariPro | milestone | 0d | 2005-05-03 A | 2005-05-03 A | 34 | 100% |  |  |  |  |  |  |  |
| 45 | 9.5 | Receive node from MariPro | milestone | 0d | 2005-05-03 A | 2005-05-03 A | 35 | 100% |  |  |  |  |  |  |  |
| 46 | 9.6 | **System Integration and Test at MBARI** |  | 411d | 2005-07-27 A | 2007-03-01 |  | 50% | 207.09d |  |  |  | 67d |  |  |
| 47 | 9.6.1 | **Fit TRF to CTA** |  | 10d | 2006-04-24 A | 2006-05-05 A | 44FS+15d, 45FS+15d | 100% |  |  |  |  |  |  |  |
| 48 | 9.6.1.1 | Test fit CTA to TRF |  | 10d | 2006-04-24 A | 2006-05-05 A |  | 100% |  |  |  |  |  |  | start no earlier than 2006-07-03 |
| 49 | 9.6.2 | **Bench test DCS, LV power sub systems Blg D, 400V power supply** |  | 235d | 2005-07-27 A | 2006-06-20 | 43, 42 | 80% | 47d |  |  |  | 213d |  |  |
| 50 | 9.6.2.1 | LV system repeat U of W FAT tests, air cooled |  | 5d | 2005-07-27 A | 2005-08-02 A |  | 100% |  |  |  |  |  |  | start no earlier than 2005-07-11 |
| 51 | 9.6.2.2 | WHOI DCS FAT's at MBARI, equip in chassis, air cooled |  | 5d | 2005-08-03 A | 2005-08-09 A | 50 | 100% |  |  |  |  |  |  |  |
| 52 | 9.6.2.3 | Wire LV comms housing, install science penetr harnesses, bulkhead penetrators, check functionality |  | 35d | 2005-08-10 A | 2005-09-27 A | 50, 51 | 100% |  |  |  |  |  |  |  |
| 53 | 9.6.2.4 | Fix T sensor and acquisition system problems |  | 90d | 2006-02-15 A | 2006-06-20 |  | 70% | 27d |  |  |  | 213d |  |  |

| ID | WBS | Task | Type | Duration | Start | Finish | Predecessors | Complete | Remaining | Baseline start | Baseline finish | Baseline duration | Total slack | Free slack | Constraint |
| --- | --- | --- | --- | --- | --- | --- | --- | --- | --- | --- | --- | --- | --- | --- | --- |
| 54 | 9.6.3 | **Bench test MV power sub systems, Blg D** |  | 15d | 2006-10-09 | 2006-10-27 | 41 |  |  |  |  |  | 14d |  |  |
| 55 | 9.6.3.1 | Alcatel deliver MV system to MBARI | milestone | 0d | 2006-10-09 | 2006-10-09 |  |  |  |  |  |  | 14d | 0d | start no earlier than 2006-10-09 |
| 56 | 9.6.3.2 | Repeat MV system acceptance tests |  | 15d | 2006-10-09 | 2006-10-27 | 55 |  |  |  |  |  | 14d |  |  |
| 57 | 9.6.4 | **I&T following delivery of reworked LV system** |  | 35d | 2006-12-15 | 2007-02-12 |  |  |  |  |  |  | 0d |  |  |
| 58 | 9.6.4.1 | Deliver LV chassis with new LV boards to MBARI | milestone | 0d | 2006-12-15 | 2006-12-15 |  |  |  |  |  |  | 0d |  | start no earlier than 2006-12-15 |
| 59 | 9.6.4.2 | Test LV, DCS system, air cooled, repeat low power acceptance tests |  | 10d | 2006-12-15 | 2007-01-08 | 58 |  |  |  |  |  | 0d |  |  |
| 60 | 9.6.4.3 | Test LV, DCS with MV system, low power |  | 10d | 2007-01-09 | 2007-01-22 | 59, 56 |  |  |  |  |  | 0d |  |  |
| 61 | 9.6.4.4 | Close up and leak test LV housing |  | 3d | 2007-01-23 | 2007-01-25 | 60 |  |  |  |  |  | 0d |  |  |
| 62 | 9.6.4.5 | Fill LV/comms housing fluorinert |  | 2d | 2007-01-26 | 2007-01-29 | 61 |  |  |  |  |  | 0d |  |  |
| 63 | 9.6.4.6 | Test LV, DCS, MV system, high power BERT test |  | 10d | 2007-01-30 | 2007-02-12 | 62 |  |  |  |  |  | 0d |  |  |
| 64 | 9.6.5 | **Node Assembly, Blg D** |  | 5d | 2007-02-13 | 2007-02-19 |  |  |  |  |  |  | 0d |  |  |
| 65 | 9.6.5.1 | Assemble MV and LV housings into node |  | 5d | 2007-02-13 | 2007-02-19 | 57 |  |  |  |  |  | 0d |  |  |
| 66 | 9.6.6 | **Tank testing** |  | 8d | 2007-02-20 | 2007-03-01 |  |  |  |  |  |  | 0d |  |  |
| 67 | 9.6.6.1 | Test node and TRF in test tank |  | 8d | 2007-02-20 | 2007-03-01 | 64 |  |  |  |  |  | 0d |  |  |
| 68 | 9.6.7 | **Ship TRF and CTA to Maersk Defender** |  | 121d | 2006-05-08 A | 2006-10-20 | 47 | 20% | 96.8d |  |  |  | 54d | 0d |  |
| 69 | 9.6.7.1 | Build supports for transportation |  | 10d | 2006-09-04 | 2006-09-15 |  |  |  |  |  |  | 79d |  | start no earlier than 2006-09-04 |
| 70 | 9.6.7.2 | Contract shipping agent |  | 20d | 2006-09-25 | 2006-10-20 |  |  |  |  |  |  | 54d |  | start no earlier than 2006-09-25 |
| 71 | 9.6.7.3 | Transport TRF to Alcatel vessel |  | 10d | 2006-05-08 A | 2006-05-19 A |  | 100% |  |  |  |  |  |  | start no earlier than 2006-05-01 |
| 72 | 9.6.7.4 | Transport CTA to Alcatel vessel |  | 10d | 2006-10-09 | 2006-10-20 |  |  |  |  |  |  | 54d |  | start no earlier than 2006-10-09 |
| 73 | 10 | **MARS Installation** |  | 94d | 2006-10-23 | 2007-03-12 |  |  |  | 2005-03-28 | 2005-05-06 | 30d | 0d |  |  |
| 74 | 10.1 | Cable and TRF installation |  | 10d | 2006-10-23 | 2006-11-03 | 68, 90 |  |  |  |  |  | 54d |  | start no earlier than 2006-09-18 |
| 75 | 10.2 | Node installation |  | 2d | 2007-03-09 | 2007-03-12 | 67FS+5d |  |  |  |  |  | 0d |  |  |
| 76 | 11 | **Shore Facility** |  | 494d | 2004-09-06 A | 2006-07-27 A |  | 100% |  | 2003-01-13 | 2004-12-31 | 515d |  |  |  |
| 77 | 11.1 | **Shore Facility** |  | 90d | 2004-09-06 A | 2005-01-07 A |  | 100% |  | 2003-01-13 | 2004-09-07 | 432d |  |  |  |
| 78 | 11.1.1 | Install PGE transformer, power pole |  | 90d | 2004-09-06 A | 2005-01-07 A |  | 100% |  |  |  |  |  |  | start no earlier than 2005-02-07 |

| ID | WBS | Task | Type | Duration | Start | Finish | Predecessors | Complete | Baseline start | Baseline finish | Baseline duration | Total slack | Constraint |
| --- | --- | --- | --- | --- | --- | --- | --- | --- | --- | --- | --- | --- | --- |
| 79 | 11.2 | **Modular Building** |  | 269d | 2004-11-08 A | 2005-11-18 A |  | 100% |  |  |  |  |  |
| 80 | 11.2.1 | Prepare requirements for modular building |  | 190d | 2004-11-08 A | 2005-08-01 A |  | 100% |  |  |  |  | start no earlier than 2004-11-08 |
| 81 | 11.2.2 | Release PO for modular building | milestone | 0d | 2005-08-08 A | 2005-08-08 A | 80 | 100% |  |  |  |  | start no earlier than 2005-08-08 |
| 82 | 11.2.3 | Deliver modular building to MBARI | milestone | 0d | 2005-11-18 A | 2005-11-18 A | 81FS+75d | 100% |  |  |  |  |  |
| 83 | 11.3 | **HDD** |  | 224d | 2005-05-16 A | 2006-03-24 A |  | 100% |  |  |  |  |  |
| 84 | 11.3.1 | Release HDD bid RFP | milestone | 0d | 2005-05-16 A | 2005-05-16 A |  | 100% |  |  |  |  | start no earlier than 2005-05-16 |
| 85 | 11.3.2 | Place contract HDD | milestone | 0d | 2005-08-08 A | 2005-08-08 A | 84FS+60d | 100% |  |  |  |  |  |
| 86 | 11.3.3 | HDD |  | 15d | 2006-03-06 A | 2006-03-24 A | 6FS+20d | 100% |  |  |  |  | start no earlier than 2006-03-06 |
| 87 | 11.4 | **Civil Work** |  | 255d | 2005-08-08 A | 2006-07-27 A |  | 100% |  |  |  |  |  |
| 88 | 11.4.1 | Complete HBFL site construction package | milestone | 0d | 2005-08-08 A | 2005-08-08 A |  | 100% |  |  |  |  | start no earlier than 2005-08-08 |
| 89 | 11.4.2 | Release civil work RFP | milestone | 0d | 2005-11-04 A | 2005-11-04 A |  | 100% |  |  |  |  | start no earlier than 2005-11-04 |
| 90 | 11.4.3 | Foundations, trench for power/comms, install ground rod conduit |  | 20d | 2006-05-15 A | 2006-06-09 A | 83FS+10d | 100% |  |  |  |  |  |
| 91 | 11.4.4 | Install modular building |  | 1d | 2006-07-03 A | 2006-07-03 A | 90FS+15d | 100% |  |  |  |  |  |
| 92 | 11.4.5 | Fit out modular building |  | 20d | 2006-07-03 A | 2006-07-27 A |  | 100% |  |  |  |  |  |
| 93 | 11.4.6 | Install land termination power and fiber to shore building |  | 5d | 2006-07-15 A | 2006-07-20 A | 91SS+10d | 100% | 2004-05-05 | 2004-09-07 | 90d |  |  |
| 94 | 12 | **Commissioning** |  | 65d | 2007-02-13 | 2007-05-14 |  |  |  |  |  | 0d |  |
| 95 | 12.1 | Move shore landing equipment rack to shore modular building |  | 5d | 2007-02-13 | 2007-02-19 | 87, 57 |  |  |  |  | 75d |  |
| 96 | 12.2 | MARS commissioning |  | 45d | 2007-03-13 | 2007-05-14 | 76, 73 |  |  |  |  | 0d |  |
