# OTE

Schedule from MS Project, 2006-10-01 to 2006-12-24.
Alcatel Submarine Networks

## Calendars

- Standard: Mon-Sun 08:00-12:00, 13:00-17:00.

## Resources

| Resource |
| --- |
| Training |
| TND |
| OTE |
| Interoute |
| ASN/NSD |
| NSD |

## Schedule

| ID | WBS | Task | Type | Duration | Start | Finish | Predecessors | Total slack | Free slack | Constraint |
| --- | --- | --- | --- | --- | --- | --- | --- | --- | --- | --- |
| 1 | 1 | **Alaskan project completion** |  | 20d | 2006-10-01 | 2006-10-20 |  | 13d |  |  |
| 2 | 1.1 | 3-week Notification to Mariners on Mars | milestone | 0d | 2006-10-01 | 2006-10-01 | 8SF-21d | 84.5d |  |  |
| 3 | 1.2 | Cut-off date for completion | milestone | 0d | 2006-10-14 | 2006-10-14 |  | 0d |  | start no earlier than 2006-10-14 |
| 4 | 1.9 | Transit to Monterey @ 12.5 knots |  | 6d | 2006-10-15 | 2006-10-20 | 3FS+1d | 0d |  |  |
| 6 | 3 | **Maersk Defender main lay and burial** |  | 26d | 2006-10-21 | 2006-11-15 |  | 0d |  |  |
| 7 | 2.1 | Clear into Monterey and embark CTA, reps and observers |  | 1d | 2006-10-21 | 2006-10-21 | 4 | 0d |  |  |
| 8 | 2.2 | Notification to Mariners in force | milestone | 0d | 2006-10-21 | 2006-10-21 | 7 | 0d |  |  |
| 9 | 3.1 | transit to site and PLGR 43 km of route (from shore to TRF location) |  | 1.5d | 2006-10-22 | 2006-10-23 | 8 | 0d |  |  |
| 10 | 2.4 | integrate and test CTA etc. |  | 1.5d | 2006-10-22 | 2006-10-23 | 7 | 0d |  |  |
| 11 | 3.2 | TRF placement at 990m WD |  | 2d | 2006-10-23 | 2006-10-25 | 10, 9 | 0d |  |  |
| 12 | 3.3 | lay and bury nominally 52 km to end of HDD pipe area |  | 3d | 2006-10-25 | 2006-10-28 | 11 | 0d |  |  |
| 13 | 3.4 | Shore-end landing into HDD pipe (first turnover cable on MD) |  | 1d | 2006-10-28 | 2006-10-29 | 12 | 0d |  |  |
| 14 | 3.5 | Post-lay inspect and bury shore-end and TRF area sections |  | 1d | 2006-10-29 | 2006-10-30 | 13 | 38.5d | 0d |  |
| 15 | 3.6 | disembark reps and clear out |  | 1d | 2006-10-30 | 2006-10-31 | 14 | 38.5d | 0d |  |
| 16 | 2.10 | contingency |  | 4d | 2006-10-31 | 2006-11-04 | 15 | 38.5d | 0d |  |
| 17 | 2.11 | transit to nominated depot @12.5 knots |  | 3d | 2006-11-04 | 2006-11-07 | 16 | 38.5d | 0d |  |
| 18 | 2.12 | offload MD spares |  | 7d | 2006-11-07 | 2006-11-14 | 17 | 38.5d | 0d |  |
| 19 | 2.13 | contingency |  | 1.5d | 2006-11-14 | 2006-11-15 | 18 | 38.5d | 0d |  |
| 20 | 2.14 | MD available for next stage | milestone | 0d | 2006-11-15 | 2006-11-15 | 19 | 38.5d |  |  |
| 22 | 4 | **Shore-end works** |  | 5d | 2006-10-27 | 2006-11-01 |  | 53d |  |  |
| 23 | 4.1 | diver support on cable insertion into HDD pipe |  | 2d | 2006-10-27 | 2006-10-29 | 12FS-1d, 4 | 56d |  |  |
| 24 | 4.2 | shore-end support on pulling cable through HDD pipe |  | 1d | 2006-10-28 | 2006-10-29 | 13SS | 54d | 0d |  |
| 25 | 4.3 | beach joint at beach manhole position (Final Splice) |  | 1d | 2006-10-29 | 2006-10-30 | 24 | 55d |  |  |
| 26 | 4.4 | diver completion of HDD pipe area |  | 2d | 2006-10-30 | 2006-11-01 | 14, 24 | 53d |  |  |

| ID | WBS | Task | Type | Duration | Start | Finish | Predecessors | Total slack |
| --- | --- | --- | --- | --- | --- | --- | --- | --- |
| 28 | 6 | **Reporting** |  | 84.5d | 2006-10-01 | 2006-12-24 |  | 0d |
| 29 | 4.1 | Pre-agreed report format in force | milestone | 0d | 2006-10-01 | 2006-10-01 |  | 42.5d |
| 30 | 6.2 | provide Provisional as-laid reports |  | 14d | 2006-11-12 | 2006-11-26 | 29, 13FS+14d | 0d |
| 31 | 6.3 | customer comments |  | 14d | 2006-11-26 | 2006-12-10 | 30 | 0d |
| 32 | 6.4 | provide Final as-laid reports |  | 14d | 2006-12-10 | 2006-12-24 | 31 | 0d |
