# OTE

Schedule from MS Project, 2006-10-20 to 2007-01-03.
Alcatel Submarine Networks

## Calendars

- Standard: Mon-Sun 08:00-12:00, 13:00-17:00.

## Resources

| Resource |
| --- |
| Training |
| TND |
| OTE |
| Interoute |
| ASN/NSD |
| NSD |

## Schedule

| ID | WBS | Task | Type | Duration | Start | Finish | Predecessors | Total slack | Free slack | Constraint |
| --- | --- | --- | --- | --- | --- | --- | --- | --- | --- | --- |
| 1 | 1 | **Alaskan project completion** |  | 12.5d | 2006-10-20 | 2006-11-01 |  | 7.5d |  |  |
| 2 | 1.1 | 3-week Notification to Mariners on Mars | milestone | 0d | 2006-10-20 | 2006-10-20 | 11SF-21d | 75.5d |  |  |
| 3 | 1.2 | Expected MD completion | milestone | 0d | 2006-10-28 | 2006-10-28 |  | 0d |  | start no earlier than 2006-10-28 |
| 4 | 1.9 | MD transit Anchorage to Portland @ 11.5 knots, clear in |  | 5d | 2006-10-28 | 2006-11-01 | 3 | 0d |  |  |
| 6 | 3 | **Global Sentinel main lay and burial** |  | 23d | 2006-11-02 | 2006-11-24 |  | 0d |  |  |
| 7 | 2.1 | Contingency |  | 2d | 2006-11-02 | 2006-11-03 | 4 | 0d |  |  |
| 8 | 2.2 | Transfer Mars onto GS from MD, embark CTA/reps/observers |  | 2d | 2006-11-04 | 2006-11-05 | 7 | 0d |  |  |
| 9 | 2.3 | Transit to Monterey (integrate CTA in passage) |  | 2.5d | 2006-11-06 | 2006-11-08 | 8 | 0d |  |  |
| 10 | 2.4 | TRF trial, ROV site inspection |  | 2d | 2006-11-08 | 2006-11-10 | 9 | 0d |  |  |
| 11 | 2.5 | Notification to Mariners in force | milestone | 0d | 2006-11-10 | 2006-11-10 | 10 | 0d |  |  |
| 12 | 3.1 | PLGR 52 km of route from TRF location to HDD entry |  | 1.5d | 2006-11-10 | 2006-11-11 | 11 | 0d |  |  |
| 13 | 3.4 | Shore-end landing into HDD pipe |  | 1d | 2006-11-12 | 2006-11-12 | 12 | 0d |  |  |
| 14 | 3.3 | lay and bury nominally 52 km to TRF end location |  | 3d | 2006-11-13 | 2006-11-15 | 13 | 0d |  |  |
| 15 | 2.9 | integrate TRF to main cable, tests |  | 0.5d | 2006-11-16 | 2006-11-16 | 14 | 0d |  |  |
| 16 | 3.2 | TRF placement at 990m WD, final tests |  | 1.5d | 2006-11-16 | 2006-11-17 | 15 | 0d |  |  |
| 17 | 3.5 | PLB TRF section, PLI Smooth Ridge, PLB HDD section |  | 1.5d | 2006-11-18 | 2006-11-19 | 16 | 0d |  |  |
| 18 | 2.12 | transit to Portland depot @11.5 knots |  | 2.5d | 2006-11-19 | 2006-11-21 | 17 | 0d |  |  |
| 19 | 3.6 | disembark reps, offload spares |  | 1d | 2006-11-22 | 2006-11-22 | 18 | 0d |  |  |
| 20 | 2.14 | contingency |  | 2d | 2006-11-23 | 2006-11-24 | 19 | 40d | 0d |  |
| 21 | 2.15 | Mars completion | milestone | 0d | 2006-11-24 | 2006-11-24 | 20 | 40d |  |  |
| 23 | 4 | **Shore-end works** |  | 3d | 2006-11-11 | 2006-11-13 |  | 51d |  |  |
| 24 | 4.1 | diver support on cable insertion into HDD pipe |  | 2d | 2006-11-11 | 2006-11-12 | 12FS-1d | 51d | 0d |  |
| 25 | 4.4 | diver completion of HDD pipe area |  | 1d | 2006-11-13 | 2006-11-13 | 24 | 51d |  |  |
| 26 | 4.2 | shore-end support on pulling cable through HDD pipe |  | 1d | 2006-11-12 | 2006-11-12 | 24SS+1d | 51d | 0d |  |
| 27 | 4.3 | shore-end support on pulling cable through into Station |  | 1d | 2006-11-13 | 2006-11-13 | 26 | 51d |  |  |

| ID | WBS | Task | Type | Duration | Start | Finish | Predecessors | Total slack |
| --- | --- | --- | --- | --- | --- | --- | --- | --- |
| 29 | 6 | **Reporting** |  | 68d | 2006-10-28 | 2007-01-03 |  | 0d |
| 30 | 4.1 | Pre-agreed report format in force | milestone | 0d | 2006-10-28 | 2006-10-28 | 3SS | 26d |
| 31 | 6.2 | provide Provisional as-laid reports |  | 14d | 2006-11-23 | 2006-12-06 | 19, 30 | 0d |
| 32 | 6.3 | customer comments |  | 14d | 2006-12-07 | 2006-12-20 | 31 | 0d |
| 33 | 6.4 | provide Final as-laid reports |  | 14d | 2006-12-21 | 2007-01-03 | 32 | 0d |
