# OTE

Schedule from MS Project, 2007-02-16 to 2007-04-30.
Alcatel Submarine Networks

## Calendars

- Standard: Mon-Sun 08:00-12:00, 13:00-17:00.

## Resources

| Resource |
| --- |
| Training |
| TND |
| OTE |
| Interoute |
| ASN/NSD |
| NSD |

## Schedule

| ID | WBS | Task | Type | Duration | Start | Finish | Predecessors | Total slack | Free slack | Constraint |
| --- | --- | --- | --- | --- | --- | --- | --- | --- | --- | --- |
| 1 | 1 | **CS Global Sentinel mobilisation** |  | 18d | 2007-02-16 | 2007-03-06 |  | 9.5d |  |  |
| 2 | 1.1 | 3-week Notification to Mariners on Mars | milestone | 0d | 2007-02-16 | 2007-02-16 | 15SF-21d | 73d |  |  |
| 3 | 1.2 | Expected Global Sentinel availability | milestone | 0d | 2007-02-26 | 2007-02-26 |  | 0d |  | start no earlier than 2007-02-26 |
| 4 | 1.3 | Transfer Mars cable onto Sentinel from Portand depot |  | 1d | 2007-02-26 | 2007-02-26 | 3 | 0d |  |  |
| 5 | 1.4 | Transfer CTA from Mbari onto Sentinel |  | 1d | 2007-02-26 | 2007-02-26 | 4SS | 62.5d |  |  |
| 6 | 1.5 | load joint kits and ancillaries |  | 1d | 2007-02-26 | 2007-02-26 | 4SS | 4d |  |  |
| 7 | 1.9 | load TRF and carry out local handling trials in this period |  | 5d | 2007-02-26 | 2007-03-02 | 4SS | 0d |  |  |
| 8 | 1.7 | Joint Mars cable into correct configuration (1 joint) |  | 1d | 2007-03-03 | 2007-03-03 | 7, 6 | 0d |  |  |
| 9 | 1.8 | Integrate CTA into TRF (1 joint) |  | 1d | 2007-03-03 | 2007-03-03 | 8SS, 6 | 0d |  |  |
| 10 | 1.9 | Contingency |  | 2.5d | 2007-03-04 | 2007-03-06 | 9 | 0d |  |  |
| 12 | 3 | **Global Sentinel main lay and burial** |  | 25.5d | 2007-03-06 | 2007-03-31 |  | 0d |  |  |
| 13 | 2.1 | Embark reps/observers |  | 0.5d | 2007-03-06 | 2007-03-06 | 10 | 0d |  |  |
| 14 | 2.2 | Transit to Monterey |  | 2.5d | 2007-03-07 | 2007-03-09 | 13 | 0d |  |  |
| 15 | 2.3 | Notification to Mariners in force | milestone | 0d | 2007-03-09 | 2007-03-09 | 14 | 0d |  |  |
| 16 | 3.1 | PLGR 52 km of route from TRF location to HDD entry |  | 1.5d | 2007-03-09 | 2007-03-10 | 15 | 0d |  |  |
| 17 | 3.4 | Shore-end landing into HDD pipe |  | 1d | 2007-03-11 | 2007-03-11 | 16 | 0d |  |  |
| 18 | 3.3 | lay and bury nominally 52 km to TRF end location |  | 3d | 2007-03-12 | 2007-03-14 | 17 | 0d |  |  |
| 19 | 2.7 | integrate TRF to main cable, tests |  | 0.5d | 2007-03-15 | 2007-03-15 | 18 | 0d |  |  |
| 20 | 3.2 | TRF placement at 990m WD, final tests |  | 1.5d | 2007-03-15 | 2007-03-16 | 19 | 0d |  |  |
| 21 | 3.5 | PLB TRF section, PLI Smooth Ridge, PLB HDD section |  | 1.5d | 2007-03-17 | 2007-03-18 | 20 | 0d |  |  |
| 22 | 3.6 | disembark reps locally (assuming possible) |  | 1d | 2007-03-18 | 2007-03-19 | 21 | 0d |  |  |
| 23 | 2.11 | contingency |  | 12.5d | 2007-03-19 | 2007-03-31 | 22 | 29.5d | 0d |  |
| 24 | 2.12 | Mars completion | milestone | 0d | 2007-03-31 | 2007-03-31 | 23 | 29.5d | 0d |  |
| 25 | 2.13 | release of Sentinel for next works (Mars spares still aboard) | milestone | 0d | 2007-03-31 | 2007-03-31 | 24 | 29.5d |  |  |

| ID | WBS | Task | Type | Duration | Start | Finish | Predecessors | Total slack | Free slack |
| --- | --- | --- | --- | --- | --- | --- | --- | --- | --- |
| 27 | 4 | **Shore-end works** |  | 9d | 2007-03-06 | 2007-03-14 |  | 46.5d |  |
| 28 | 3.1 | shore-end team mob |  | 0.99d | 2007-03-06 | 2007-03-06 | 29SF-0.01d | 54.51d |  |
| 29 | 3.2 | site and HDD pipe preparation |  | 3.99d | 2007-03-07 | 2007-03-10 | 30SF-0.01d | 50.51d | 0d |
| 30 | 4.1 | diver support on cable insertion into HDD pipe |  | 1d | 2007-03-11 | 2007-03-11 | 17SS | 49.5d | 0d |
| 31 | 4.2 | shore-end support on pulling cable through HDD pipe |  | 1d | 2007-03-11 | 2007-03-11 | 17SS | 46.5d | 0d |
| 32 | 4.4 | diver completion of HDD pipe area |  | 2d | 2007-03-12 | 2007-03-13 | 31 | 47.5d |  |
| 33 | 4.3 | shore-end support on pulling cable through into Station |  | 3d | 2007-03-12 | 2007-03-14 | 31 | 46.5d |  |
| 35 | 4 | **Oil Spillage** |  | 9d | 2007-03-09 | 2007-03-18 |  | 43d |  |
| 36 | 4.1 | mobilised on site | milestone | 0d | 2007-03-09 | 2007-03-09 | 16SS | 52d |  |
| 37 | 4.2 | demobilised off site | milestone | 0d | 2007-03-18 | 2007-03-18 | 21FF | 43d |  |
| 39 | 6 | **Reporting** |  | 63.5d | 2007-02-26 | 2007-04-30 |  | 0d |  |
| 40 | 5.1 | Pre-agreed report format in force | milestone | 0d | 2007-02-26 | 2007-02-26 | 3SS | 21.5d |  |
| 41 | 6.2 | provide Provisional as-laid reports |  | 14d | 2007-03-19 | 2007-04-02 | 22, 40 | 0d |  |
| 42 | 6.3 | customer comments |  | 14d | 2007-04-02 | 2007-04-16 | 41 | 0d |  |
| 43 | 6.4 | provide Final as-laid reports |  | 14d | 2007-04-16 | 2007-04-30 | 42 | 0d |  |
